Schedule from MS Project, 2002-01-01 to 2003-11-01, 24 hours a day.
NAMA SA

## Calendars

- 24 Hours: Mon-Sun 00:00-24:00.

## Resources

| Resource |
| --- |
| Εργοδότης |
| Προιστάμενη Αρχή |
| Διευθύνουσα Υπηρεσία |
| Γενικός Μελετητής |
| Αλλοι τοπικοί φορείς |
| Μελετητές |
| Γεωλόγος |
| Δνση Χωροταξίας ΥΠΕΧΩΔΕ |
| ΓΓ Περίφέρειας |
| Δνση Χωροταξίας (Κεντρική ή Περιφερειακή) |
| Υπουργείο Γεωργείας |
| ΥΠΠΟ |
| ΥΠΕΧΩΔΕ/Περιβάλλον |
| Τοπογράφος |
| Γεωτεχνικός |
| Κυκλοφοριολόγος |
| Μελετητης Περιβαλλοντολόγος |
| Δνση Περιβαλλοντικού Σχεδιασμού |
| Δνση Περιβαλλοντος και Χωροταξίας Γενικής Γραμματείας της Περιφέρειας |
| Νομαρχιακό Συμβούλιο |
| Ενδιαφερόμενο Κοινό |
| Εδαφοτεχνικός Μελετητης |
| Συγκοινωνιλόγος Μηχανικός |
| Κύριος του Έργου |
| Γενικός Μελετητής(Ειδικός Συγκοινωνιολόγος) |
| Μελετήτής Οικονομολόγος |
| Δνση Χωροταξίας ΥΠΕΧΩΔΕ ή ΔΙΠΕΧΩ ΓΓ Περίφέρειας |
| ΥΠΕΧΩΔΕ |
| Ηλεκτρολόγος-Μηχανολόγος |
| Συναρμόδιες Υπηρεσίες |
| Ειδικό Εργαστήριο |
| Επιτροπή καθορισμού της Γραμμής Αιγιαλού & Παραλίας |
| ΔΤΥΝΑ (Δνση Τεχνικών Υπηρεσιών της αρμόδιας Νομαρχιακής Αυτοδιοίκησης) |
| Κτηματική Υπηρεσία του Νομού |
| Υπ. Οκονομικών |
| ΥΕΝ |
| ΓΕΝ |
| ΕΥΠΕ/ΥΠΕΧΩΔΕ ή ΔΙΠΕΧΩ ΓΓ Περιφέρειας |
| Συναρμόδιοι Υπουργοί |
| Συναρμόδια Υπουργεία |

## Schedule

| ID | WBS | Task | Type | Duration | Start | Finish | Predecessors | Baseline start | Baseline finish | Baseline duration | Total slack | Free slack | Resources | Work | Text1 |
| --- | --- | --- | --- | --- | --- | --- | --- | --- | --- | --- | --- | --- | --- | --- | --- |
| 1 | 1 | Μελέτη Γενικού Σχεδιασμού | milestone | 1d? | 2002-01-01 | 2002-01-02 |  |  |  |  | 699d |  | ΥΕΝ | 24h |  |
| 2 | 2 | **Διαδικασία Επιλογής Μελετητή** |  | 181d | 2002-01-01 | 2002-07-01 |  |  |  |  | 0d |  |  | 864h | 6Μ |
| 3 | 2.1 | Δημοσίευση Προκήρυξης Μελέτης |  | 44d | 2002-01-01 | 2002-02-14 |  | 2002-01-11 | 2002-01-11 | 0.33d? | 0d |  | Εργοδότης | 288h | 1.5Μ |
| 4 | 2.2 | Αξιολόγηση Υποψήφιων Μελετητών |  | 15d | 2002-02-14 | 2002-03-01 | 3 | 2002-02-10 | 2002-03-12 | 30d | 0d |  | Εργοδότης | 112h | 0.5Μ |
| 5 | 2.3 | Επιλογή Μελετητή |  | 15d | 2002-03-01 | 2002-03-16 | 4 | 2002-03-12 | 2002-03-27 | 15d | 0d |  | Εργοδότης | 64h | 0.5Μ |
| 6 | 2.4 | Κοινοποίηση Απόφασης Ανάθεσης |  | 15d | 2002-03-16 | 2002-03-31 | 5 | 2002-03-27 | 2002-04-11 | 15d | 0d |  | Εργοδότης | 48h | 0.5Μ |
| 7 | 2.5 | Διαδικασία Ενστάσεων |  | 76d | 2002-03-31 | 2002-06-15 | 6 | 2002-04-11 | 2002-06-30 | 80d | 0d |  | Εργοδότης | 288h | 2.5Μ |
| 8 | 2.6 | Ανάθεση Μελέτης |  | 16d | 2002-06-15 | 2002-07-01 | 7 | 2002-06-30 | 2002-06-30 | 0d? | 0d |  | Εργοδότης | 64h | 0.5Μ |
| 9 | 3 | Κατάρτιση και Υπογραφή Σύμβασης |  | 31d | 2002-07-01 | 2002-08-01 | 8 |  |  |  | 0d |  | Εργοδότης; Προιστάμενη Αρχή; Διευθύνουσα Υπηρεσία; Γενικός Μελετητής | 2976h | 1Μ |
| 10 | 4 | Επίβλεψη Μελέτης |  | 457d | 2002-08-01 | 2003-11-01 | 9 |  |  |  | 0d |  | Διευθύνουσα Υπηρεσία; Γενικός Μελετητής | 21936h | 15Μ |
| 11 | 5 | Εποπτεία Μελέτης |  | 457d | 2002-08-01 | 2003-11-01 | 10SS |  |  |  | 0d |  | Προιστάμενη Αρχή; Γενικός Μελετητής | 21936h | 15Μ |
| 12 | 6 | **ΣΤΑΔΙΟ Ι: Προκαταρκτικές Μελέτες** |  | 153d | 2002-08-01 | 2003-01-01 | 9 |  |  |  | 0d |  |  | 4792h | 5Μ |
| 13 | 6.1 | Εντολή Έναρξης Σταδίου Ι | milestone | 0d | 2002-08-01 | 2002-08-01 |  |  |  |  | 0d |  | Εργοδότης |  | 0Μ |
| 14 | 6.2 | Αναγνώριση Έργου - Συγκέντρωση Στοιχείων |  | 31d | 2002-08-01 | 2002-09-01 | 13 |  |  |  | 0d |  | Διευθύνουσα Υπηρεσία; Γενικός Μελετητής; Αλλοι τοπικοί φορείς | 528h | 1Μ |
| 15 | 6.3 | Μελέτη Σκοπιμότητας |  | 30d | 2002-09-01 | 2002-10-01 | 14 |  |  |  | 0d |  | Γενικός Μελετητής | 720h | 1Μ |
| 16 | 6.4 | Έγκριση Μελέτης Σκοπιμότητας |  | 30d | 2002-10-01 | 2002-10-31 | 15 |  |  |  | 0d |  | Διευθύνουσα Υπηρεσία | 720h | 1Μ |
| 17 | 6.5 | Πρόγραμμα Τοπογρ. - Βυθομετρ. Εργασιών |  | 31d | 2002-09-01 | 2002-10-02 | 14 |  |  |  | 578d | 0d | Διευθύνουσα Υπηρεσία; Γενικός Μελετητής | 368h | 1Μ |
| 18 | 6.6 | Έγκριση Προγράμματος Τοπογρ. - Βυθομετρ. Εργασίων |  | 31d | 2002-10-02 | 2002-11-02 | 17 |  |  |  | 578d | 0d | Εργοδότης | 168h | 1Μ |
| 19 | 6.7 | Εκτέλεση Τοπογρ. - Βυθομετρ. Εργασιών |  | 30d | 2002-11-02 | 2002-12-02 | 18 |  |  |  | 578d |  | Διευθύνουσα Υπηρεσία; Γενικός Μελετητής; Τοπογράφος | 528h | 1Μ |
| 20 | 6.8 | Εκπόνηση Προκαταρκτικών Μελέτών |  | 92d | 2002-09-01 | 2002-12-02 | 16FS-60d |  |  |  | 0d |  | Διευθύνουσα Υπηρεσία; Γενικός Μελετητής | 1056h | 3Μ |
| 21 | 6.9 | Πρόγραμμα Γεωτεχνικών Ερευνών |  | 30d | 2002-12-02 | 2003-01-01 | 20 |  |  |  | 0d |  | Διευθύνουσα Υπηρεσία; Γενικός Μελετητής | 352h | 1Μ |
| 22 | 6.10 | Πρόγραμμα Εργαστηριακών Δοκιμών |  | 30d | 2002-12-02 | 2003-01-01 | 20 |  |  |  | 0d |  | Γενικός Μελετητής; Διευθύνουσα Υπηρεσία | 352h | 1Μ |
| 23 | 7 | Εγκριση Σταδίου Ι |  | 31d | 2003-01-01 | 2003-02-01 | 22, 21 |  |  |  | 0d |  | Εργοδότης | 168h | 1Μ |
| 24 | 8 | Εγκριση Εργαστηριακών Δοκιμών (Ομοιώματος) |  | 30d | 2003-01-01 | 2003-01-31 | 23SS |  |  |  | 518d |  | Διευθύνουσα Υπηρεσία; Ειδικό Εργαστήριο; Γενικός Μελετητής | 2160h | 1Μ |
| 25 | 9 | Εκτέλεση Γεωτεχνικών Ερευνών |  | 60d | 2003-02-01 | 2003-04-02 | 23 |  |  |  | 457d |  | Διευθύνουσα Υπηρεσία; Εδαφοτεχνικός Μελετητης | 672h | 2Μ |
| 26 | 10 | Διαδικασίες Έκδοσης Πιστοποιητικών Αξιοπλοϊας & Καθορισμού Σήμανσης |  | 182d | 2003-02-01 | 2003-08-02 | 23 |  |  |  | 122d |  |  |  | 6Μ |

| ID | WBS | Task | Type | Duration | Start | Finish | Predecessors | Baseline start | Baseline finish | Baseline duration | Total slack | Free slack | Resources | Work | Text1 |
| --- | --- | --- | --- | --- | --- | --- | --- | --- | --- | --- | --- | --- | --- | --- | --- |
| 27 | 11 | **ΣΤΑΔΙΟ ΙΙ: Προμελέτες - Μελέτη Περιβαλλοντικών Επιπτώσεων** |  | 182d | 2003-02-01 | 2003-08-02 | 23 |  |  |  | 0d |  |  | 8616h | 6Μ |
| 28 | 11.1 | Εντολή Έναρξης Σταδίου ΙΙ | milestone | 0d | 2003-02-01 | 2003-02-01 |  |  |  |  | 0d |  | Εργοδότης |  | 0Μ |
| 29 | 11.2 | Εκπόνηση Προμελέτης |  | 89d | 2003-02-01 | 2003-05-01 | 28 |  |  |  | 215d | 0d | Διευθύνουσα Υπηρεσία; Γενικός Μελετητής | 4272h | 3Μ |
| 30 | 11.3 | Εκπόνηση Οικονομοτεχνικής Μελέτης |  | 59d | 2003-02-01 | 2003-04-01 | 29SS, 28 |  |  |  | 276d |  | Διευθύνουσα Υπηρεσία; Γενικός Μελετητής; Μελετήτής Οικονομολόγος | 1056h | 2Μ |
| 31 | 11.4 | Εκτέλεση Εργαστηριακών Δοκιμών |  | 59d | 2003-02-01 | 2003-04-01 | 28 |  |  |  | 276d |  | Διευθύνουσα Υπηρεσία; Μελετητές | 704h | 2Μ |
| 32 | 11.5 | Εκπόνηση ΜΠΕ |  | 59d | 2003-02-01 | 2003-04-01 | 28 |  |  |  | 0d |  | Διευθύνουσα Υπηρεσία; Γενικός Μελετητής; Μελετητης Περιβαλλοντολόγος | 1032h | 2Μ |
| 33 | 11.6 | **Διαδικασίες Έκδοσης Απόφασης Έγκρισης Περιβαλλοντικών Όρων** |  | 123d | 2003-04-01 | 2003-08-02 | 32 |  |  |  | 0d |  |  | 1552h | 4Μ |
| 34 | 11.6.1 | Παραλάβή ΜΠΕ-¨Ελεγχος-Υποβολή |  | 15d | 2003-04-01 | 2003-04-16 |  | 2003-11-26 | 2003-12-11 | 15d | 0d |  | Διευθύνουσα Υπηρεσία | 88h | 0.5Μ |
| 35 | 11.6.2 | Παραλαβή της ΜΠΕ-Έλεγχος-Διαβίβαση |  | 15d | 2003-04-16 | 2003-05-01 | 34 | 2003-12-11 | 2004-01-10 | 30d | 0d |  | ΕΥΠΕ/ΥΠΕΧΩΔΕ ή ΔΙΠΕΧΩ ΓΓ Περιφέρειας | 88h | 0.5Μ |
| 36 | 11.6.3 | Παραλαβή της ΜΠΕ-Γνωμοδότηση-Διαβίβαση |  | 15d | 2003-05-01 | 2003-05-16 | 35 | 2003-12-26 | 2004-01-10 | 15d | 78d |  | Συναρμόδια Υπουργεία | 88h | 0.5Μ |
| 37 | 11.6.4 | Νομαρχιακό Συμβούλιο: Παραλαβή-Δημοσίευση Ανάρτηση ΜΠΕ |  | 15d | 2003-05-01 | 2003-05-16 | 35 | 2004-01-10 | 2004-02-09 | 30d | 0d |  | Νομαρχιακό Συμβούλιο | 168h | 0.5Μ |
| 38 | 11.6.5 | Διατύπωση Απόψεων - Αντιρρήσεων - Προτάσεων |  | 15d | 2003-05-09 | 2003-05-24 | 37FS-7d | 2004-01-25 | 2004-02-14 | 20d | 0d |  | Ενδιαφερόμενο Κοινό | 112h | 0.5Μ |
| 39 | 11.6.6 | Νομαρχιακό Συμβούλιο: Κριτική Άποψη Διαβίβαση |  | 15d | 2003-05-18 | 2003-06-02 | 38FS-6d | 2004-02-14 | 2004-02-29 | 15d | 0d |  | Νομαρχιακό Συμβούλιο | 88h | 0.5Μ |
| 40 | 11.6.7 | Σύνταξη Σχεδίου Απόφασης Έγκρισης περιβαλλοντικών όρων |  | 30d | 2003-06-02 | 2003-07-02 | 39 | 2004-02-29 | 2004-03-15 | 15d | 0d |  | ΕΥΠΕ/ΥΠΕΧΩΔΕ ή ΔΙΠΕΧΩ ΓΓ Περιφέρειας | 176h | 1Μ |
| 41 | 11.6.8 | Υπογραφή Υπουργών η Γ.Γ. Περιφέρειας |  | 16d | 2003-07-02 | 2003-07-18 | 40 | 2004-03-15 | 2004-03-31 | 16d | 0d |  | ΥΠΕΧΩΔΕ; ΓΓ Περίφέρειας; ΥΕΝ; Συναρμόδιοι Υπουργοί | 656h | 0.5Μ |
| 42 | 11.6.9 | Έκδοση Απόφασης ¨Εγκρισης Περιβαλλοντικών Όρων |  | 15d | 2003-07-18 | 2003-08-02 | 41 | 2004-03-31 | 2004-03-31 | 0d? | 0d |  | ΕΥΠΕ/ΥΠΕΧΩΔΕ ή ΔΙΠΕΧΩ ΓΓ Περιφέρειας | 88h | 0.5Μ |
| 43 | 12 | Έγκριση Σταδίου ΙΙ |  | 31d | 2003-07-02 | 2003-08-02 | 33FF |  |  |  | 0d |  | Εργοδότης | 168h | 1Μ |
| 44 | 13 | **ΣΤΑΔΙΟ ΙΙΙ: Σύνταξη Τευχών Δημοπράτησης** |  | 61d | 2003-08-02 | 2003-10-02 | 43 |  |  |  | 0d |  |  | 704h | 8Μ |
| 45 | 13.1 | Εντολή Έναρξης Σταδίου ΙΙΙ | milestone | 0d | 2003-08-02 | 2003-08-02 |  |  |  |  | 153d |  | Εργοδότης |  | 0Μ |
| 46 | 13.2 | Σύνταξη Τευχών Δημοπράτησης |  | 61d | 2003-08-02 | 2003-10-02 |  |  |  |  | 0d |  | Διευθύνουσα Υπηρεσία; Γενικός Μελετητής | 704h | 2Μ |
| 47 | 14 | Έγκριση Σταδίου ΙΙΙ (Τευχών Δημοπράτησης) |  | 30d | 2003-10-02 | 2003-11-01 | 46 |  |  |  | 0d |  | Εργοδότης | 168h | 1Μ |
