Schedule from MS Project, 2002-01-01 to 2004-11-01, 24 hours a day.
NAMA SA

## Calendars

- 24 Hours: Mon-Sun 00:00-24:00.

## Resources

| Resource |
| --- |
| Εργοδότης |
| Προιστάμενη Αρχή |
| Διευθύν. Υπηρεσία |
| Γεν. Μελετητής |
| Αλλοι τοπικοί φορείς |
| Μελετητές |
| Γεωλόγος |
| Δνση Χωροταξίας ΥΠΕΧΩΔΕ |
| ΓΓ Περίφέρειας |
| Δνση Χωροταξίας (Κεντρική ή Περιφερειακή) |
| Υπουργείο Γεωργείας |
| ΥΠΠΟ |
| ΥΠΕΧΩΔΕ/Περιβάλλον |
| Τοπογράφος |
| Γεωτεχνικός |
| Κυκλοφοριολόγος |
| Μελετητης Περιβαλλοντολόγος |
| Δνση Περιβαλλοντικού Σχεδιασμού |
| Δνση Περιβαλλοντος και Χωροταξίας Γενικής Γραμματείας της Περιφέρειας |
| Νομαρχιακό Συμβούλιο |
| Ενδιαφερόμενο Κοινό |
| Εδαφοτεχνικός Μελετητης |
| Συγκοινωνιλόγος Μηχανικός |
| Κύριος του Έργου |
| Γενικός Μελετητής(Ειδικός Συγκοινωνιολόγος) |
| Μελετήτής Οικονομολόγος |
| Δνση Χωροταξίας ΥΠΕΧΩΔΕ ή ΔΙΠΕΧΩ ΓΓ Περίφέρειας |
| ΥΠΕΧΩΔΕ |
| Ηλεκτρολόγος-Μηχανολόγος |
| Συναρμόδιες Υπηρεσίες |
| Ειδικό Εργαστήριο |
| Επιτροπή καθορισμού της Γραμμής Αιγιαλού & Παραλίας |
| ΔΤΥΝΑ |
| Κτηματ. Υπηρεσία του Νομού |
| Υπ. Οικον. |
| ΥΕΝ |
| ΓΕΝ |
| ΕΥΠΕ/ΥΠΕΧΩΔΕ ή ΔΙΠΕΧΩ ΓΓ Περιφέρειας |
| Συναρμόδιοι Υπουργοί |
| Συναρμόδια Υπουργεία |

## Schedule

| ID | WBS | Task | Type | Duration | Start | Finish | Predecessors | Baseline start | Baseline finish | Baseline duration | Total slack | Free slack | Resources | Work | Text1 |
| --- | --- | --- | --- | --- | --- | --- | --- | --- | --- | --- | --- | --- | --- | --- | --- |
| 1 | 1 | Μελέτη Γενικού Σχεδιασμού | milestone | 1d? | 2002-01-01 | 2002-01-02 |  |  |  |  | 1066d |  | ΥΕΝ | 24h | 0Μ |
| 2 | 2 | **Διαδικασία Επιλογής Μελετητή** |  | 181d | 2002-01-01 | 2002-07-01 |  |  |  |  | 0d |  |  | 864h | 6Μ |
| 3 | 2.1 | Δημοσίευση Προκήρυξης Μελέτης |  | 44d | 2002-01-01 | 2002-02-14 |  | 2002-01-11 | 2002-01-11 | 0.33d? | 0d |  | Εργοδότης | 288h | 1.5Μ |
| 4 | 2.2 | Αξιολόγηση Υποψήφιων Μελετητών |  | 15d | 2002-02-14 | 2002-03-01 | 3 | 2002-02-10 | 2002-03-12 | 30d | 0d |  | Εργοδότης | 112h | 0.5Μ |
| 5 | 2.3 | Επιλογή Μελετητή |  | 15d | 2002-03-01 | 2002-03-16 | 4 | 2002-03-12 | 2002-03-27 | 15d | 0d |  | Εργοδότης | 64h | 0.5Μ |
| 6 | 2.4 | Κοινοποίηση Απόφασης Ανάθεσης |  | 15d | 2002-03-16 | 2002-03-31 | 5 | 2002-03-27 | 2002-04-11 | 15d | 0d |  | Εργοδότης | 48h | 0.5Μ |
| 7 | 2.5 | Διαδικασία Ενστάσεων |  | 76d | 2002-03-31 | 2002-06-15 | 6 | 2002-04-11 | 2002-06-30 | 80d | 0d |  | Εργοδότης | 288h | 2.5Μ |
| 8 | 2.6 | Ανάθεση Μελέτης |  | 16d | 2002-06-15 | 2002-07-01 | 7 | 2002-06-30 | 2002-06-30 | 0d? | 0d |  | Εργοδότης | 64h | 0.5Μ |
| 9 | 3 | Κατάρτιση και Υπογραφή Σύμβασης |  | 30d | 2002-07-01 | 2002-07-31 | 8 |  |  |  | 0d |  | Εργοδότης; Προιστάμενη Αρχή; Διευθύν. Υπηρεσία; Γεν. Μελετητής | 2880h | 1Μ |
| 10 | 4 | Επίβλεψη Μελέτης |  | 823d | 2002-07-31 | 2004-10-31 | 9 |  |  |  | 2d | 0d | Διευθύν. Υπηρεσία; Γεν. Μελετητής | 39504h | 27Μ |
| 11 | 5 | Εποπτεία Μελέτης |  | 823d | 2002-07-31 | 2004-10-31 | 10SS |  |  |  | 2d |  | Προιστάμενη Αρχή; Γεν. Μελετητής | 39504h | 27Μ |
| 12 | 6 | **ΣΤΑΔΙΟ Ι** |  | 243d | 2002-07-31 | 2003-03-31 | 9 |  |  |  | 0d |  |  | 5720h | 8Μ |
| 13 | 6.1 | Εντολή Έναρξης Σταδίου Ι | milestone | 0d | 2002-07-31 | 2002-07-31 |  |  |  |  | 0d |  | Εργοδότης |  | 0Μ |
| 14 | 6.2 | Αναγνώριση Έργου - Συγκέντρωση Στοιχείων |  | 31d | 2002-07-31 | 2002-08-31 | 13 |  |  |  | 0d |  | Διευθύν. Υπηρεσία; Γεν. Μελετητής; Αλλοι τοπικοί φορείς | 528h | 1Μ |
| 15 | 6.3 | Μελέτη Σκοπιμότητας |  | 30d | 2002-08-31 | 2002-09-30 | 14 |  |  |  | 0d |  | Γεν. Μελετητής | 720h | 1Μ |
| 16 | 6.4 | Έγκριση Μελέτης Σκοπιμότητας |  | 30d | 2002-09-30 | 2002-10-30 | 15 |  |  |  | 0d |  | Διευθύν. Υπηρεσία | 720h | 1Μ |
| 17 | 6.5 | Πρόγραμμα Τοπογρ. - Βυθομετρ. Εργασιών |  | 31d | 2002-08-31 | 2002-10-01 | 14 |  |  |  | 730d | 0d | Διευθύν. Υπηρεσία; Γεν. Μελετητής | 368h | 1Μ |
| 18 | 6.6 | Έγκριση Προγράμματος Τοπογρ. - Βυθομετρ. Εργασίων |  | 31d | 2002-10-01 | 2002-11-01 | 17 |  |  |  | 730d | 0d | Εργοδότης | 168h | 1Μ |
| 19 | 6.7 | Εκτέλεση Τοπογρ. - Βυθομετρ. Εργασιών |  | 30d | 2002-11-01 | 2002-12-01 | 18 |  |  |  | 730d |  | Διευθύν. Υπηρεσία; Γεν. Μελετητής; Τοπογράφος | 528h | 1Μ |
| 20 | 6.8 | Εκπόνηση Προκαταρκτικών Μελέτών |  | 92d | 2002-08-31 | 2002-12-01 | 16FS-60d |  |  |  | 0d |  | Διευθύν. Υπηρεσία; Γεν. Μελετητής | 1056h | 3Μ |
| 21 | 6.9 | Πρόγραμμα Γεωτεχνικών Ερευνών |  | 30d | 2002-12-01 | 2002-12-31 | 20 |  |  |  | 700d |  | Διευθύν. Υπηρεσία; Γεν. Μελετητής | 352h | 1Μ |
| 22 | 6.10 | Πρόγραμμα Εργαστηριακών Δοκιμών |  | 30d | 2002-12-01 | 2002-12-31 | 20 |  |  |  | 700d |  | Γεν. Μελετητής; Διευθύν. Υπηρεσία | 352h | 1Μ |
| 23 | 6.11 | Εκπόνηση Προμελέτης Περιβαλλοντικών Επιπτώσεων-Π.Π.Ε. (Φ.Π.Χ.) |  | 31d | 2002-12-01 | 2003-01-01 | 20 |  |  |  | 0d |  | Διευθύν. Υπηρεσία; Γεν. Μελετητής | 352h | 1Μ |
| 24 | 6.12 | **Διαδικασίες Εκδοσης Προκαταρκτικής Περιβαλλοντικής Εκτίμησης και Αξιολόγησης (Π.Χ.)** |  | 89d | 2003-01-01 | 2003-03-31 | 23 |  |  |  | 0d |  |  | 576h | 3Μ |
| 25 | 6.12.1 | Παραλαβή Π.Π.Ε (Φ.Π.Χ.) - Έλεγχος - Υποβολή |  | 15d | 2003-01-01 | 2003-01-16 |  | 2003-03-01 | 2003-03-04 | 3d | 0d |  | Διευθύν. Υπηρεσία | 80h | 0.5Μ |
| 26 | 6.12.2 | Παραλαβή Π.Π.Ε (Φ.Π.Χ.) - Γνωμοδοτήσεις Συναρμοδιών |  | 60d | 2003-01-16 | 2003-03-17 | 25 | 2003-03-04 | 2003-03-07 | 3d | 0d |  | Συναρμόδιες Υπηρεσίες; ΕΥΠΕ/ΥΠΕΧΩΔΕ ή ΔΙΠΕΧΩ ΓΓ Περιφέρειας | 416h | 2Μ |
| 27 | 6.12.3 | Έκδοση Προκαταρκτικής Περιβαλλοντικής Εκτίμησης και Αξιολόγησης (Π.Χ.) |  | 14d | 2003-03-17 | 2003-03-31 | 26 | 2003-03-25 | 2003-03-31 | 6d | 0d |  | ΕΥΠΕ/ΥΠΕΧΩΔΕ ή ΔΙΠΕΧΩ ΓΓ Περιφέρειας | 80h | 0.5Μ |
| 28 | 7 | Εγκριση Σταδίου Ι |  | 31d | 2003-03-31 | 2003-05-01 | 27 |  |  |  | 0d |  | Εργοδότης | 168h | 1Μ |
| 29 | 8 | Εγκριση Εργαστηριακών Δοκιμών (Ομοιώματος) |  | 30d | 2003-03-31 | 2003-04-30 | 28SS |  |  |  | 583d |  | Διευθύν. Υπηρεσία; Ειδικό Εργαστήριο; Γεν. Μελετητής | 2160h | 1Μ |
| 30 | 9 | Εκτέλεση Γεωτεχνικών Ερευνών |  | 60d | 2003-05-01 | 2003-06-30 | 28 |  |  |  | 0d |  | Διευθύν. Υπηρεσία; Εδαφοτεχνικός Μελετητης | 672h | 2Μ |

| ID | WBS | Task | Type | Duration | Start | Finish | Predecessors | Baseline start | Baseline finish | Baseline duration | Total slack | Free slack | Resources | Work | Text1 |
| --- | --- | --- | --- | --- | --- | --- | --- | --- | --- | --- | --- | --- | --- | --- | --- |
| 31 | 10 | **Καθορισμός Αιγιαλού & Παραλίας - Παραχώρηση Χρήσης** |  | 306d | 2003-05-01 | 2004-03-02 | 28 |  |  |  | 273d |  |  | 18360h | 19Μ |
| 32 | 10.1 | Καθορισμός Γραμμής Αιγιαλού και Παραλίας |  | 153d | 2003-05-01 | 2003-10-01 |  |  |  |  | 3d | 0d | Επιτροπή καθορισμού της Γραμμής Αιγιαλού & Παραλίας | 3672h | 5Μ |
| 33 | 10.2 | Παραχώρηση Απλής Χρήσης Αιγιαλού και Παραλίας προς Εκτέλεση Έργων |  | 153d | 2003-10-01 | 2004-03-02 | 32 |  |  |  | 3d | 0d | Κύριος του Έργου; ΔΤΥΝΑ; Κτηματ. Υπηρεσία του Νομού; Υπ. Οικον. | 14688h | 5Μ |
| 34 | 11 | **ΣΤΑΔΙΟ ΙΙ** |  | 185d | 2003-06-30 | 2004-01-01 | 28, 30 |  |  |  | 0d |  |  | 4304h | 6Μ |
| 35 | 11.1 | Εντολή Έναρξης Σταδίου ΙΙ | milestone | 0d | 2003-06-30 | 2003-06-30 |  |  |  |  | 0d |  | Εργοδότης |  | 0Μ |
| 36 | 11.2 | Εκπόνηση Οικονομοτεχνικής Μελέτης |  | 63d | 2003-06-30 | 2003-09-01 | 35 |  |  |  | 459d |  | Διευθύν. Υπηρεσία; Γεν. Μελετητής; Μελετήτής Οικονομολόγος | 1056h | 2Μ |
| 37 | 11.3 | Εκτέλεση Εργαστηριακών Δοκιμών |  | 63d | 2003-06-30 | 2003-09-01 | 35 |  |  |  | 459d |  | Διευθύν. Υπηρεσία; Μελετητές | 704h | 2Μ |
| 38 | 11.4 | Εκπόνηση Μ.Π.Ε |  | 63d | 2003-06-30 | 2003-09-01 | 35 |  |  |  | 0d |  | Διευθύν. Υπηρεσία; Γεν. Μελετητής; Μελετητης Περιβαλλοντολόγος | 1032h | 2Μ |
| 39 | 11.5 | **Διαδικασίες Έκδοσης Απόφασης Έγκρισης Περιβαλλοντικών Όρων** |  | 122d | 2003-09-01 | 2004-01-01 | 38 |  |  |  | 0d |  |  | 1512h | 4Μ |
| 40 | 11.5.1 | Παραλάβή Μ.Π.Ε-¨Ελεγχος-Υποβολή |  | 15d | 2003-09-01 | 2003-09-16 |  | 2003-11-26 | 2003-12-11 | 15d | 0d |  | Διευθύν. Υπηρεσία | 88h | 0.5Μ |
| 41 | 11.5.2 | Παραλαβή της Μ.Π.Ε-Έλεγχος-Διαβίβαση |  | 15d | 2003-09-16 | 2003-10-01 | 40 | 2003-12-11 | 2004-01-10 | 30d | 0d |  | ΕΥΠΕ/ΥΠΕΧΩΔΕ ή ΔΙΠΕΧΩ ΓΓ Περιφέρειας | 88h | 0.5Μ |
| 42 | 11.5.3 | Παραλαβή της Μ.Π.Ε-Γνωμοδότηση-Διαβίβαση |  | 15d | 2003-10-01 | 2003-10-16 | 41 | 2003-12-26 | 2004-01-10 | 15d | 77d |  | Συναρμόδια Υπουργεία | 88h | 0.5Μ |
| 43 | 11.5.4 | Νομαρχιακό Συμβούλιο: Παραλαβή-Δημοσίευση Ανάρτηση ΜΠΕ |  | 15d | 2003-10-01 | 2003-10-16 | 41 | 2004-01-10 | 2004-02-09 | 30d | 0d |  | Νομαρχιακό Συμβούλιο | 168h | 0.5Μ |
| 44 | 11.5.5 | Διατύπωση Απόψεων - Αντιρρήσεων - Προτάσεων |  | 15d | 2003-10-09 | 2003-10-24 | 43FS-7d | 2004-01-25 | 2004-02-14 | 20d | 0d |  | Ενδιαφερόμενο Κοινό | 112h | 0.5Μ |
| 45 | 11.5.6 | Νομαρχιακό Συμβούλιο: Κριτική Άποψη Διαβίβαση |  | 15d | 2003-10-18 | 2003-11-02 | 44FS-6d | 2004-02-14 | 2004-02-29 | 15d | 0d |  | Νομαρχιακό Συμβούλιο | 88h | 0.5Μ |
| 46 | 11.5.7 | Σύνταξη Σχεδίου Απόφασης Έγκρισης Περιβαλλοντικών Όρων |  | 30d | 2003-11-02 | 2003-12-02 | 45 | 2004-02-29 | 2004-03-15 | 15d | 0d |  | ΕΥΠΕ/ΥΠΕΧΩΔΕ ή ΔΙΠΕΧΩ ΓΓ Περιφέρειας | 168h | 1Μ |
| 47 | 11.5.8 | Υπογραφή Υπουργών η Γ.Γ. Περιφέρειας |  | 15d | 2003-12-02 | 2003-12-17 | 46 | 2004-03-15 | 2004-03-31 | 16d | 0d |  | ΥΠΕΧΩΔΕ; ΓΓ Περίφέρειας; ΥΕΝ; Συναρμόδιοι Υπουργοί | 624h | 0.5Μ |
| 48 | 11.5.9 | Έκδοση Απόφασης Έγκρισης Περιβαλλοντικών Όρων |  | 15d | 2003-12-17 | 2004-01-01 | 47 | 2004-03-31 | 2004-03-31 | 0d? | 0d |  | ΕΥΠΕ/ΥΠΕΧΩΔΕ ή ΔΙΠΕΧΩ ΓΓ Περιφέρειας | 88h | 0.5Μ |
| 49 | 12 | Έγκριση Σταδίου ΙΙ |  | 31d | 2004-01-01 | 2004-02-01 | 39 |  |  |  | 0d |  | Εργοδότης | 168h | 1Μ |
| 50 | 13 | **ΣΤΑΔΙΟ ΙΙΙ** |  | 243d | 2004-02-01 | 2004-10-01 | 49 |  |  |  | 0d |  |  | 2784h | 8Μ |
| 51 | 13.1 | Εντολή Έναρξης Σταδίου ΙΙΙ | milestone | 0d | 2004-02-01 | 2004-02-01 |  |  |  |  | 274d |  | Εργοδότης |  | 0Μ |
| 52 | 13.2 | Εκπόνηση Οριστικών Μελετών |  | 182d | 2004-02-01 | 2004-08-01 |  |  |  |  | 0d |  | Διευθύν. Υπηρεσία; Γεν. Μελετητής | 2080h | 6Μ |
| 53 | 13.3 | Σύνταξη Τευχών Δημοπράτησης |  | 61d | 2004-08-01 | 2004-10-01 | 52 |  |  |  | 0d |  | Διευθύν. Υπηρεσία; Γεν. Μελετητής | 704h | 2Μ |
| 54 | 14 | Έγκριση Σταδίου ΙΙΙ |  | 31d | 2004-10-01 | 2004-11-01 | 53 |  |  |  | 0d |  | Εργοδότης | 168h | 1Μ |
