Schedule from MS Project, 2002-01-01 to 2004-04-01, 24 hours a day.
NAMA SA

## Calendars

- 24 Hours: Mon-Sun 00:00-24:00.

## Resources

| Resource |
| --- |
| Εργοδότης |
| Προιστάμενη Αρχή |
| Διευθύν. Υπηρεσία |
| Γεν. Μελετητής |
| Αλλοι τοπικοί φορείς |
| Μελετητές |
| Γεωλόγος |
| Δνση Χωροταξίας ΥΠΕΧΩΔΕ |
| ΓΓ Περίφέρειας |
| Δνση Χωροταξίας (Κεντρική ή Περιφερειακή) |
| Υπουργείο Γεωργείας |
| ΥΠΠΟ |
| ΥΠΕΧΩΔΕ/Περιβάλλον |
| Τοπογράφος |
| Γεωτεχνικός |
| Κυκλοφοριολόγος |
| Μελετητης Περιβαλλοντολόγος |
| Δνση Περιβαλλοντικού Σχεδιασμού |
| Δνση Περιβαλλοντος και Χωροταξίας Γενικής Γραμματείας της Περιφέρειας |
| Νομαρχιακό Συμβούλιο |
| Ενδιαφερόμενο Κοινό |
| Εδαφοτεχνικός Μελετητης |
| Συγκοινωνιλόγος Μηχανικός |
| Κύριος του Έργου |
| Γενικός Μελετητής(Ειδικός Συγκοινωνιολόγος) |
| Μελετήτής Οικονομολόγος |
| Δνση Χωροταξίας ΥΠΕΧΩΔΕ ή ΔΙΠΕΧΩ ΓΓ Περίφέρειας |
| ΥΠΕΧΩΔΕ |
| Ηλεκτρολόγος-Μηχανολόγος |
| Συναρμόδιες Υπηρεσίες |
| Ειδικό Εργαστήριο |
| Επιτροπή καθορισμού της Γραμμής Αιγιαλού & Παραλίας |
| ΔΤΥΝΑ |
| Κτηματ. Υπηρεσία του Νομού |
| Υπ. Οικον. |
| ΥΕΝ |
| ΓΕΝ |
| ΕΥΠΕ/ΥΠΕΧΩΔΕ ή ΔΙΠΕΧΩ ΓΓ Περιφέρειας |
| Συναρμόδιοι Υπουργοί |
| Συναρμόδια Υπουργεία |

## Schedule

| ID | WBS | Task | Type | Duration | Start | Finish | Predecessors | Baseline start | Baseline finish | Baseline duration | Total slack | Free slack | Resources | Work | Text1 |
| --- | --- | --- | --- | --- | --- | --- | --- | --- | --- | --- | --- | --- | --- | --- | --- |
| 1 | 1 | **Διαδικασία Επιλογής Μελετητή** |  | 181d | 2002-01-01 | 2002-07-01 |  |  |  |  | 0d |  |  | 864h | 6Μ |
| 2 | 1.1 | Δημοσίευση Προκήρυξης Μελέτης |  | 44d | 2002-01-01 | 2002-02-14 |  | 2002-01-11 | 2002-01-11 | 0.33d? | 0d |  | Εργοδότης | 288h | 1.5Μ |
| 3 | 1.2 | Αξιολόγηση Υποψήφιων Μελετητών |  | 15d | 2002-02-14 | 2002-03-01 | 2 | 2002-02-10 | 2002-03-12 | 30d | 0d |  | Εργοδότης | 112h | 0.5Μ |
| 4 | 1.3 | Επιλογή Μελετητή |  | 15d | 2002-03-01 | 2002-03-16 | 3 | 2002-03-12 | 2002-03-27 | 15d | 0d |  | Εργοδότης | 64h | 0.5Μ |
| 5 | 1.4 | Κοινοποίηση Απόφασης Ανάθεσης |  | 15d | 2002-03-16 | 2002-03-31 | 4 | 2002-03-27 | 2002-04-11 | 15d | 0d |  | Εργοδότης | 48h | 0.5Μ |
| 6 | 1.5 | Διαδικασία Ενστάσεων |  | 76d | 2002-03-31 | 2002-06-15 | 5 | 2002-04-11 | 2002-06-30 | 80d | 0d |  | Εργοδότης | 288h | 2.5Μ |
| 7 | 1.6 | Ανάθεση Μελέτης |  | 16d | 2002-06-15 | 2002-07-01 | 6 | 2002-06-30 | 2002-06-30 | 0d? | 0d |  | Εργοδότης | 64h | 0.5Μ |
| 8 | 2 | Κατάρτιση και Υπογραφή Σύμβασης |  | 30d | 2002-07-01 | 2002-07-31 | 7 |  |  |  | 0d |  | Εργοδότης; Προιστάμενη Αρχή; Διευθύν. Υπηρεσία; Γεν. Μελετητής | 2880h | 1Μ |
| 9 | 3 | Επίβλεψη Μελέτης |  | 610d | 2002-07-31 | 2004-04-01 | 8 |  |  |  | 0d |  | Διευθύν. Υπηρεσία; Γεν. Μελετητής | 29280h | 20Μ |
| 10 | 4 | Εποπτεία Μελέτης |  | 610d | 2002-07-31 | 2004-04-01 | 9SS |  |  |  | 0d |  | Προιστάμενη Αρχή; Γεν. Μελετητής | 29280h | 20Μ |
| 11 | 5 | **ΣΤΑΔΙΟ Ι** |  | 243d | 2002-07-31 | 2003-03-31 | 8 |  |  |  | 0d |  |  | 5720h | 8Μ |
| 12 | 5.1 | Εντολή Έναρξης Σταδίου Ι | milestone | 0d | 2002-07-31 | 2002-07-31 |  |  |  |  | 0d |  | Εργοδότης |  | 0Μ |
| 13 | 5.2 | Αναγνώριση Έργου - Συγκέντρωση Στοιχείων |  | 31d | 2002-07-31 | 2002-08-31 | 12 |  |  |  | 0d |  | Διευθύν. Υπηρεσία; Γεν. Μελετητής; Αλλοι τοπικοί φορείς | 528h | 1Μ |
| 14 | 5.3 | Μελέτη Σκοπιμότητας |  | 30d | 2002-08-31 | 2002-09-30 | 13 |  |  |  | 0d |  | Γεν. Μελετητής | 720h | 1Μ |
| 15 | 5.4 | Έγκριση Μελέτης Σκοπιμότητας |  | 30d | 2002-09-30 | 2002-10-30 | 14 |  |  |  | 0d |  | Διευθύν. Υπηρεσία | 720h | 1Μ |
| 16 | 5.5 | Πρόγραμμα Τοπογρ. - Βυθομετρ. Εργασιών |  | 31d | 2002-08-31 | 2002-10-01 | 13 |  |  |  | 730d | 0d | Διευθύν. Υπηρεσία; Γεν. Μελετητής | 368h | 1Μ |
| 17 | 5.6 | Έγκριση Προγράμματος Τοπογρ. - Βυθομετρ. Εργασίων |  | 31d | 2002-10-01 | 2002-11-01 | 16 |  |  |  | 730d | 0d | Εργοδότης | 168h | 1Μ |
| 18 | 5.7 | Εκτέλεση Τοπογρ. - Βυθομετρ. Εργασιών |  | 30d | 2002-11-01 | 2002-12-01 | 17 |  |  |  | 730d |  | Διευθύν. Υπηρεσία; Γεν. Μελετητής; Τοπογράφος | 528h | 1Μ |
| 19 | 5.8 | Εκπόνηση Προκαταρκτικών Μελέτών |  | 92d | 2002-08-31 | 2002-12-01 | 15FS-60d |  |  |  | 0d |  | Διευθύν. Υπηρεσία; Γεν. Μελετητής | 1056h | 3Μ |
| 20 | 5.9 | Πρόγραμμα Γεωτεχνικών Ερευνών |  | 30d | 2002-12-01 | 2002-12-31 | 19 |  |  |  | 700d |  | Διευθύν. Υπηρεσία; Γεν. Μελετητής | 352h | 1Μ |
| 21 | 5.10 | Πρόγραμμα Εργαστηριακών Δοκιμών |  | 30d | 2002-12-01 | 2002-12-31 | 19 |  |  |  | 700d |  | Γεν. Μελετητής; Διευθύν. Υπηρεσία | 352h | 1Μ |
| 22 | 5.11 | Εκπόνηση Προμελέτης Περιβαλλοντικών Επιπτώσεων - Π.Π.Ε. (Φ.Π.Χ.) |  | 31d | 2002-12-01 | 2003-01-01 | 19 |  |  |  | 0d |  | Διευθύν. Υπηρεσία; Γεν. Μελετητής | 352h | 1Μ |
| 23 | 5.12 | **Διαδικασίες Εκδοσης Προκαταρκτικής Περιβαλλοντικής Εκτίμησης και Αξιολόγησης (Π.Χ.)** |  | 89d | 2003-01-01 | 2003-03-31 | 22 |  |  |  | 0d |  |  | 576h | 3Μ |
| 24 | 5.12.1 | Παραλαβή Π.Π.Ε. (Φ.Π.Χ.) - Έλεγχος - Υποβολή |  | 15d | 2003-01-01 | 2003-01-16 |  | 2003-03-01 | 2003-03-04 | 3d | 0d |  | Διευθύν. Υπηρεσία | 80h | 0.5Μ |
| 25 | 5.12.2 | Παραλαβή Π.Π.Ε. (Φ.Π.Χ.) - Γνωμοδοτήσεις Συναρμοδιών |  | 60d | 2003-01-16 | 2003-03-17 | 24 | 2003-03-04 | 2003-03-07 | 3d | 0d |  | Συναρμόδιες Υπηρεσίες; ΕΥΠΕ/ΥΠΕΧΩΔΕ ή ΔΙΠΕΧΩ ΓΓ Περιφέρειας | 416h | 2Μ |
| 26 | 5.12.3 | Έκδοση Προκαταρκτικής Περιβαλλοντικής Εκτίμησης και Αξιολόγησης (Π.Χ.) |  | 14d | 2003-03-17 | 2003-03-31 | 25, 28FS-5d | 2003-03-25 | 2003-03-31 | 6d | 0d |  | ΕΥΠΕ/ΥΠΕΧΩΔΕ ή ΔΙΠΕΧΩ ΓΓ Περιφέρειας | 80h | 0.5Μ |

| ID | WBS | Task | Type | Duration | Start | Finish | Predecessors | Baseline start | Baseline finish | Baseline duration | Total slack | Free slack | Resources | Work | Text1 |
| --- | --- | --- | --- | --- | --- | --- | --- | --- | --- | --- | --- | --- | --- | --- | --- |
| 27 | 6 | **Εγκριση Σταδίου Ι** |  | 31d | 2003-03-31 | 2003-05-01 | 26 |  |  |  | 0d |  | Εργοδότης | 168h | 1Μ |
| 28 | 6.1 | Μελέτη Γενικού Σχεδιασμού |  | 15d | 2003-03-06 | 2003-03-21 |  |  |  |  | 0d |  | ΥΕΝ | 720h | 0Μ |
| 29 | 7 | Εγκριση Εργαστηριακών Δοκιμών (Ομοιώματος) |  | 31d | 2003-03-31 | 2003-05-01 | 27SS |  |  |  | 367d |  | Διευθύν. Υπηρεσία; Ειδικό Εργαστήριο; Γεν. Μελετητής | 2232h | 1Μ |
| 30 | 8 | Εκτέλεση Γεωτεχνικών Ερευνών |  | 60d | 2003-05-01 | 2003-06-30 | 27 |  |  |  | 0d |  | Διευθύν. Υπηρεσία; Εδαφοτεχνικός Μελετητης | 672h | 2Μ |
| 31 | 9 | **Καθορισμός Αιγιαλού & Παραλίας - Παραχώρηση Χρήσης** |  | 244d | 2003-05-01 | 2003-12-31 | 27 |  |  |  | 92d |  |  | 14640h | 19Μ |
| 32 | 9.1 | Καθορισμός Γραμμής Αιγιαλού και Παραλίας |  | 122d | 2003-05-01 | 2003-08-31 |  |  |  |  | 123d | 0d | Επιτροπή καθορισμού της Γραμμής Αιγιαλού & Παραλίας | 2928h | 4Μ |
| 33 | 9.2 | Παραχώρηση Απλής Χρήσης Αιγιαλού και Παραλίας προς Εκτέλεση Έργων |  | 122d | 2003-08-31 | 2003-12-31 | 32 |  |  |  | 123d |  | Κύριος του Έργου; ΔΤΥΝΑ; Κτηματ. Υπηρεσία του Νομού; Υπ. Οικον. | 11712h | 4Μ |
| 34 | 10 | **ΣΤΑΔΙΟ ΙΙ** |  | 186d | 2003-06-30 | 2004-01-02 | 27, 30 |  |  |  | 0d |  |  | 8728h | 6Μ |
| 35 | 10.1 | Εντολή Έναρξης Σταδίου ΙΙ | milestone | 0d | 2003-06-30 | 2003-06-30 |  |  |  |  | 0d |  | Εργοδότης |  | 0Μ |
| 36 | 10.2 | Εκπόνηση Προμελέτης |  | 92d | 2003-06-30 | 2003-09-30 | 35 |  |  |  | 215d | 0d | Διευθύν. Υπηρεσία; Γεν. Μελετητής | 4416h | 3Μ |
| 37 | 10.3 | Εκπόνηση Οικονομοτεχνικής Μελέτης |  | 63d | 2003-06-30 | 2003-09-01 | 36SS, 35 |  |  |  | 244d |  | Διευθύν. Υπηρεσία; Γεν. Μελετητής; Μελετήτής Οικονομολόγος | 1056h | 2Μ |
| 38 | 10.4 | Εκτέλεση Εργαστηριακών Δοκιμών |  | 63d | 2003-06-30 | 2003-09-01 | 36SS, 35 |  |  |  | 244d |  | Διευθύν. Υπηρεσία; Μελετητές | 704h | 2Μ |
| 39 | 10.5 | Εκπόνηση Μελέτης Περιβαλλοντικών Επιπτώσεων |  | 63d | 2003-06-30 | 2003-09-01 | 35 |  |  |  | 0d |  | Διευθύν. Υπηρεσία; Γεν. Μελετητής; Μελετητης Περιβαλλοντολόγος | 1032h | 2Μ |
| 40 | 10.6 | **Διαδικασίες Έκδοσης Απόφασης Έγκρισης Περιβαλλοντικών Όρων** |  | 123d | 2003-09-01 | 2004-01-02 | 39 |  |  |  | 0d |  |  | 1520h | 4Μ |
| 41 | 10.6.1 | Παραλάβή Μ.Π.Ε-Έλεγχος-Υποβολή |  | 15d | 2003-09-01 | 2003-09-16 |  | 2003-11-26 | 2003-12-11 | 15d | 0d |  | Διευθύν. Υπηρεσία | 88h | 0.5Μ |
| 42 | 10.6.2 | Παραλαβή της Μ.Π.Ε-Έλεγχος-Διαβίβαση |  | 15d | 2003-09-16 | 2003-10-01 | 41 | 2003-12-11 | 2004-01-10 | 30d | 0d |  | ΕΥΠΕ/ΥΠΕΧΩΔΕ ή ΔΙΠΕΧΩ ΓΓ Περιφέρειας | 88h | 0.5Μ |
| 43 | 10.6.3 | Παραλαβή της Μ.Π.Ε-Γνωμοδότηση-Διαβίβαση |  | 15d | 2003-10-01 | 2003-10-16 | 42 | 2003-12-26 | 2004-01-10 | 15d | 78d |  | Συναρμόδια Υπουργεία | 88h | 0.5Μ |
| 44 | 10.6.4 | Νομαρχιακό Συμβούλιο: Παραλαβή-Δημοσίευση Ανάρτηση Μ.Π.Ε |  | 15d | 2003-10-01 | 2003-10-16 | 42 | 2004-01-10 | 2004-02-09 | 30d | 0d |  | Νομαρχιακό Συμβούλιο | 168h | 0.5Μ |
| 45 | 10.6.5 | Διατύπωση Απόψεων - Αντιρρήσεων - Προτάσεων |  | 15d | 2003-10-09 | 2003-10-24 | 44FS-7d | 2004-01-25 | 2004-02-14 | 20d | 0d |  | Ενδιαφερόμενο Κοινό | 112h | 0.5Μ |
| 46 | 10.6.6 | Νομαρχιακό Συμβούλιο: Κριτική Άποψη Διαβίβαση |  | 15d | 2003-10-18 | 2003-11-02 | 45FS-6d | 2004-02-14 | 2004-02-29 | 15d | 0d |  | Νομαρχιακό Συμβούλιο | 88h | 0.5Μ |
| 47 | 10.6.7 | Σύνταξη Σχεδίου Απόφασης Έγκρισης Περιβαλλοντικών Όρων |  | 31d | 2003-11-02 | 2003-12-03 | 46 | 2004-02-29 | 2004-03-15 | 15d | 0d |  | ΕΥΠΕ/ΥΠΕΧΩΔΕ ή ΔΙΠΕΧΩ ΓΓ Περιφέρειας | 176h | 1Μ |
| 48 | 10.6.8 | Υπογραφή Υπουργών η Γ.Γ. Περιφέρειας |  | 15d | 2003-12-03 | 2003-12-18 | 47 | 2004-03-15 | 2004-03-31 | 16d | 0d |  | ΥΠΕΧΩΔΕ; ΓΓ Περίφέρειας; ΥΕΝ; Συναρμόδιοι Υπουργοί | 624h | 0.5Μ |
| 49 | 10.6.9 | Έκδοση Απόφασης Έγκρισης Περιβαλλοντικών Όρων |  | 15d | 2003-12-18 | 2004-01-02 | 48 | 2004-03-31 | 2004-03-31 | 0d? | 0d |  | ΕΥΠΕ/ΥΠΕΧΩΔΕ ή ΔΙΠΕΧΩ ΓΓ Περιφέρειας | 88h | 0.5Μ |
| 50 | 11 | Έγκριση Σταδίου ΙΙ |  | 31d | 2003-12-02 | 2004-01-02 | 40FF |  |  |  | 0d |  | Εργοδότης | 168h | 1Μ |

| ID | WBS | Task | Type | Duration | Start | Finish | Predecessors | Total slack | Resources | Work | Text1 |
| --- | --- | --- | --- | --- | --- | --- | --- | --- | --- | --- | --- |
| 51 | 12 | **ΣΤΑΔΙΟ ΙΙΙ** |  | 59d | 2004-01-02 | 2004-03-01 | 50 | 0d |  | 704h | 2Μ |
| 52 | 12.1 | Εντολή Έναρξης Σταδίου ΙΙΙ | milestone | 0d | 2004-01-02 | 2004-01-02 |  | 121d | Εργοδότης |  | 0Μ |
| 53 | 12.2 | Σύνταξη Τευχών Δημοπράτησης |  | 59d | 2004-01-02 | 2004-03-01 |  | 0d | Διευθύν. Υπηρεσία; Γεν. Μελετητής | 704h | 2Μ |
| 54 | 13 | Έγκριση Σταδίου ΙΙΙ (Τευχών Δημοπράτησης) |  | 31d | 2004-03-01 | 2004-04-01 | 53 | 0d | Εργοδότης | 168h | 1Μ |
